Schedule from MS Project, 2008-02-11 to 2008-05-28, A marks actual dates.

## Calendars

- 24 Hours: Mon-Sat 08:00-12:00, 13:00-17:00; Sun off. Exceptions (off unless hours are given): 2008-02-15 08:00-12:00, 13:00-17:00, 2008-02-16, 2008-02-22 08:00-12:00, 13:00-17:00, 2008-02-23, 2008-02-29 to 2008-03-01 08:00-12:00, 13:00-17:00, 2008-03-07 to 2008-03-08 08:00-12:00, 13:00-17:00, 2008-03-14 to 2008-03-15 08:00-12:00, 13:00-17:00, 2008-03-21 to 2008-03-22 08:00-12:00, 13:00-17:00, 2008-03-28 to 2008-03-29 08:00-12:00, 13:00-17:00, 2008-04-27 08:00-12:00, 13:00-17:00.

## Resources

| Resource |
| --- |
| Andrew |
| Tom |
| Jacob |
| Dustin |
| Mike |
| J |

## Schedule

| ID | WBS | Task | Duration | Start | Finish | Predecessors | Complete | Remaining | Total slack | Constraint | Resources | Work | Actual work |
| --- | --- | --- | --- | --- | --- | --- | --- | --- | --- | --- | --- | --- | --- |
| 1 | 1 | **Particle Panic** | 91d? | 2008-02-11 A | 2008-05-28 |  | 98% | 1.76d? | 0d |  |  | 10536h | 7713.67h |
| 2 | 1.1 | **Graphics Engine** | 70d | 2008-02-11 A | 2008-05-02 |  | 92% | 5.83d | 21d |  | Mike | 1736h | 984.03h |
| 3 | 1.1.1 | **Renderer** | 68d | 2008-02-13 A | 2008-05-02 |  | 85% | 10.2d | 21d |  | Mike | 840h | 371.04h |
| 4 | 1.1.1.1 | **Basic Implementation** | 3d | 2008-02-13 A | 2008-02-15 A |  | 100% |  |  |  | Mike | 48h | 48h |
| 5 | 1.1.1.1.1 | Render Node Class | 1d | 2008-02-13 A | 2008-02-13 A |  | 100% |  |  |  | Mike | 8h | 8h |
| 6 | 1.1.1.1.2 | Appearance Class | 1d | 2008-02-14 A | 2008-02-14 A |  | 100% |  |  | start no earlier than 2008-02-14 | Mike | 8h | 8h |
| 7 | 1.1.1.1.3 | Direct3D Interface | 1d | 2008-02-15 A | 2008-02-15 A |  | 100% |  |  | start no earlier than 2008-02-15 | Mike | 8h | 8h |
| 8 | 1.1.1.2 | **Scene Management** | 14d | 2008-04-18 A | 2008-05-02 |  | 73% | 3.82d | 21d |  | Mike | 200h | 111.27h |
| 9 | 1.1.1.2.1 | Frustum Culling | 3d | 2008-04-18 | 2008-04-21 | 7 |  |  | 32d | start no earlier than 2008-04-18 | Mike | 24h |  |
| 10 | 1.1.1.2.2 | Depth Sorting | 3d | 2008-04-23 A | 2008-04-25 A | 4 | 100% |  |  | start no earlier than 2008-04-23 | Mike | 24h | 24h |
| 11 | 1.1.1.2.3 | Alpha Blending | 5d | 2008-04-28 A | 2008-05-02 A | 4 | 100% |  |  | start no earlier than 2008-04-28 | Mike | 40h | 40h |
| 12 | 1.1.1.3 | Testing | 2d | 2008-02-18 A | 2008-02-19 A | 7 | 100% |  |  | start no earlier than 2008-02-19 | Mike | 16h | 16h |
| 13 | 1.1.1.4 | Integration | 1d | 2008-02-20 A | 2008-02-20 A | 12 | 100% |  |  | start no earlier than 2008-02-21 | Mike | 8h | 8h |
| 14 | 1.1.1.5 | Shader Refactoring | 3d | 2008-04-14 A | 2008-04-16 A |  | 100% |  |  | start no earlier than 2008-04-14 | Mike | 24h | 24h |
| 15 | 1.1.2 | **Texture Manager** | 4d | 2008-02-21 A | 2008-02-26 A | 4 | 100% |  |  |  | Mike | 40h | 40h |
| 16 | 1.1.2.1 | Basic Implementation | 1d | 2008-02-21 A | 2008-02-21 A |  | 100% |  |  | start no earlier than 2008-02-26 | Mike | 8h | 8h |
| 17 | 1.1.2.2 | File I/O | 1d | 2008-02-22 A | 2008-02-22 A | 16 | 100% |  |  | start no earlier than 2008-02-22 | Mike | 8h | 8h |
| 18 | 1.1.2.3 | Testing | 1d | 2008-02-25 A | 2008-02-25 A | 17 | 100% |  |  |  | Mike | 8h | 8h |
| 19 | 1.1.2.4 | Integration | 1d | 2008-02-26 A | 2008-02-26 A | 18 | 100% |  |  |  | Mike | 8h | 8h |
| 20 | 1.1.3 | **SIMD Math Library** | 4d | 2008-03-13 A | 2008-03-17 A |  | 100% |  |  |  | Mike | 64h | 64h |
| 21 | 1.1.3.1 | Implementaion | 1d | 2008-03-13 A | 2008-03-13 A |  | 100% |  |  | start no earlier than 2008-03-13 | Mike | 8h | 8h |
| 22 | 1.1.3.2 | Integration | 3d | 2008-03-14 A | 2008-03-17 A | 21 | 100% |  |  |  | Mike | 24h | 24h |
| 23 | 1.1.4 | **Shader Manager** | 10d | 2008-03-12 A | 2008-03-22 A |  | 100% |  |  |  | Mike | 128h | 128h |
| 24 | 1.1.4.1 | Basic Iimplementation | 1d | 2008-03-12 A | 2008-03-12 A |  | 100% |  |  | start no earlier than 2008-03-12 | Mike | 8h | 8h |
| 25 | 1.1.4.2 | File I/O | 1d | 2008-03-18 A | 2008-03-18 A | 24 | 100% |  |  | start no earlier than 2008-03-18 | Mike | 8h | 8h |
| 26 | 1.1.4.3 | Testing | 1d | 2008-03-19 A | 2008-03-19 A | 25 | 100% |  |  |  | Mike | 8h | 8h |
| 27 | 1.1.4.4 | Integration | 3d | 2008-03-20 A | 2008-03-22 A | 26 | 100% |  |  | start no earlier than 2008-03-17 | Mike | 24h | 24h |

| ID | WBS | Task | Duration | Start | Finish | Predecessors | Complete | Remaining | Total slack | Constraint | Resources | Work | Actual work |
| --- | --- | --- | --- | --- | --- | --- | --- | --- | --- | --- | --- | --- | --- |
| 28 | 1.1.5 | **Mesh Manager** | 13d | 2008-02-11 A | 2008-02-27 A |  | 100% |  |  |  | Mike | 120h | 120h |
| 29 | 1.1.5.1 | Basic Implementation | 1d | 2008-02-11 A | 2008-02-11 A |  | 100% |  |  | start no earlier than 2008-02-11 | Mike | 8h | 8h |
| 30 | 1.1.5.2 | Integration | 1d | 2008-02-27 A | 2008-02-27 A | 19 | 100% |  |  | start no earlier than 2008-02-27 | Mike | 8h | 8h |
| 31 | 1.2 | **Input** | 71d | 2008-02-13 A | 2008-05-06 |  | 78% | 15.78d | 18d |  |  | 96h | 80h |
| 32 | 1.2.1 | Basic Implementation | 1d | 2008-02-13 A | 2008-02-13 A |  | 100% |  |  |  | Andrew | 8h | 8h |
| 33 | 1.2.2 | XInput | 1d | 2008-02-14 A | 2008-02-14 A | 32 | 100% |  |  |  | Andrew | 8h | 8h |
| 34 | 1.2.3 | **Direct Input** | 69d | 2008-02-15 A | 2008-05-06 |  | 33% | 46d | 18d |  |  | 24h | 8h |
| 35 | 1.2.3.1 | Mouse-Camera Rotation | 1d | 2008-02-15 A | 2008-02-15 A |  | 100% |  |  | start no earlier than 2008-02-15 | Andrew | 8h | 8h |
| 36 | 1.2.3.2 | Key Mapping | 2d | 2008-05-05 | 2008-05-06 |  |  |  | 18d | start no earlier than 2008-05-05 | Andrew | 16h |  |
| 37 | 1.2.4 | **Testing** | 3d | 2008-02-18 A | 2008-02-20 A | 33 | 100% |  |  |  | Andrew | 48h | 48h |
| 38 | 1.2.4.1 | Polarity Manipulation | 2d | 2008-02-18 A | 2008-02-19 A |  | 100% |  |  | start no earlier than 2008-02-18 | Andrew | 16h | 16h |
| 39 | 1.2.4.2 | Smooth Camera Operation | 1d | 2008-02-20 A | 2008-02-20 A | 38 | 100% |  |  |  | Andrew | 8h | 8h |
| 40 | 1.2.5 | Integration | 1d | 2008-02-21 A | 2008-02-21 A | 39 | 100% |  |  | start no earlier than 2008-02-21 | Andrew | 8h | 8h |
| 41 | 1.3 | **Physics Engine** | 51d | 2008-02-11 A | 2008-04-11 |  | 99% | 0d | 0d |  | Mike | 808h | 524h |
| 42 | 1.3.1 | **Baisc Implementation** | 38d | 2008-02-28 A | 2008-04-11 |  | 99% | 0d | 0d |  | Mike | 328h | 144h |
| 43 | 1.3.1.1 | Physics Node Class | 1d | 2008-02-28 A | 2008-02-28 A |  | 100% |  |  | start no earlier than 2008-02-29 | Mike | 8h | 8h |
| 44 | 1.3.1.2 | Collision Callback System | 3d | 2008-03-06 A | 2008-04-11 A |  | 100% |  |  | start no earlier than 2008-03-06 | Mike | 24h | 24h |
| 45 | 1.3.2 | **Collision** | 3d | 2008-03-03 A | 2008-03-05 A |  | 100% |  |  |  | Mike | 32h | 32h |
| 46 | 1.3.2.1 | Sphere | 1d | 2008-03-03 A | 2008-03-03 A |  | 100% |  |  | start no earlier than 2008-03-05 | Mike | 8h | 8h |
| 47 | 1.3.2.2 | Plane | 1d | 2008-03-04 A | 2008-03-04 A |  | 100% |  |  | start no earlier than 2008-03-06 | Mike | 8h | 8h |
| 48 | 1.3.2.3 | AABB | 1d | 2008-03-05 A | 2008-03-05 A |  | 100% |  |  | start no earlier than 2008-03-05 | Mike | 8h | 8h |
| 49 | 1.3.3 | **Movement** | 15d | 2008-02-11 A | 2008-02-29 A |  | 100% |  |  |  | Mike | 136h | 136h |
| 50 | 1.3.3.1 | Basic Velocity | 1d | 2008-02-11 A | 2008-02-11 A |  | 100% |  |  | start no earlier than 2008-03-06 | Mike | 8h | 8h |
| 51 | 1.3.3.2 | Gravitational Displacement | 1d | 2008-02-29 A | 2008-02-29 A |  | 100% |  |  | start no earlier than 2008-03-07 | Mike | 8h | 8h |
| 52 | 1.3.4 | Testing | 3d | 2008-03-07 A | 2008-03-10 A | 51 | 100% |  |  | start no earlier than 2008-03-07 | Mike | 24h | 24h |
| 53 | 1.3.5 | Integration | 1d | 2008-03-11 A | 2008-03-11 A | 52 | 100% |  |  | start no earlier than 2008-03-10 | Mike | 8h | 8h |

| ID | WBS | Task | Duration | Start | Finish | Predecessors | Complete | Remaining | Total slack | Constraint | Resources | Work | Actual work |
| --- | --- | --- | --- | --- | --- | --- | --- | --- | --- | --- | --- | --- | --- |
| 54 | 1.4 | **HUD** | 82d? | 2008-02-13 A | 2008-05-19 |  | 99% | 0d? | 0d |  | J | 1152h | 633.14h |
| 55 | 1.4.1 | Internal Data Passing | 1d | 2008-02-13 A | 2008-02-13 A |  | 100% |  |  |  | J | 8h | 8h |
| 56 | 1.4.2 | Rendering | 1d | 2008-02-14 A | 2008-02-14 A | 55 | 100% |  |  |  | J | 8h | 8h |
| 57 | 1.4.3 | External Data Syncing | 1d | 2008-02-15 A | 2008-02-15 A | 56 | 100% |  |  |  | J | 8h | 8h |
| 58 | 1.4.4 | Testing | 1d | 2008-02-20 A | 2008-02-20 A | 57 | 100% |  |  | start no earlier than 2008-02-20 | J | 8h | 8h |
| 59 | 1.4.5 | Integration | 1d | 2008-02-21 A | 2008-02-21 A | 58 | 100% |  |  |  | J | 8h | 8h |
| 60 | 1.4.6 | Placeholder Asset Creation | 5d? | 2008-04-09 A | 2008-04-14 A |  | 100% |  |  | start no earlier than 2008-04-09 | J | 40h | 40h |
| 61 | 1.4.7 | Render-Based Refactoring | 4d? | 2008-04-15 A | 2008-04-18 A |  | 100% |  |  | start no earlier than 2008-04-15 | J | 32h | 32h |
| 62 | 1.4.8 | Energy Bar Redux | 2d? | 2008-04-21 A | 2008-04-22 A |  | 100% |  |  | start no earlier than 2008-04-21 | J | 16h | 16h |
| 63 | 1.4.9 | Slingshot Bar | 4d? | 2008-04-25 A | 2008-04-28 A |  | 100% |  |  | finish no earlier than 2008-02-14 | J | 32h | 32h |
| 64 | 1.4.10 | **2D Asset Creation** | 15d? | 2008-05-02 A | 2008-05-19 A |  | 100% |  |  |  | J | 240h | 240h |
| 65 | 1.4.10.1 | Menu Boxes | 3d? | 2008-05-02 A | 2008-05-05 A |  | 100% |  |  | start no earlier than 2008-05-02 | J | 24h | 24h |
| 66 | 1.4.10.2 | **Splash Screens** | 12d? | 2008-05-06 A | 2008-05-19 A |  | 100% |  |  |  |  | 96h | 96h |
| 67 | 1.4.10.2.1 | Tutorial Levels | 3d? | 2008-05-06 A | 2008-05-08 A |  | 100% |  |  | start no earlier than 2008-05-13 | J | 24h | 24h |
| 68 | 1.4.10.2.2 | Campaign Levels | 3d? | 2008-05-09 A | 2008-05-12 A |  | 100% |  |  | start no earlier than 2008-05-08 | J | 24h | 24h |
| 69 | 1.4.10.2.3 | Control Screens | 3d? | 2008-05-13 A | 2008-05-15 A |  | 100% |  |  | start no earlier than 2008-05-14 | J | 24h | 24h |
| 70 | 1.4.10.2.4 | Developer Logo | 3d? | 2008-05-16 A | 2008-05-19 A |  | 100% |  |  | start no earlier than 2008-05-16 | J | 24h | 24h |
| 71 | 1.4.11 | **Advanced HUD Effects** | 34d? | 2008-03-25 A | 2008-05-01 A |  | 100% |  |  |  |  | 96h | 96h |
| 72 | 1.4.11.1 | Energy Subtraction Overlay | 1d | 2008-03-25 A | 2008-03-25 A |  | 100% |  |  | start no earlier than 2008-03-31 | J | 8h | 8h |
| 73 | 1.4.11.2 | Rotating Polarity Rays | 3d | 2008-03-26 A | 2008-03-28 A |  | 100% |  |  | start no earlier than 2008-03-26 | J | 24h | 24h |
| 74 | 1.4.11.3 | Textual Feedback | 3d | 2008-03-31 A | 2008-04-02 A |  | 100% |  |  | start no earlier than 2008-04-02 | J | 24h | 24h |
| 75 | 1.4.11.4 | Energy Cell Shrinking | 2d? | 2008-04-23 A | 2008-04-24 A |  | 100% |  |  | start no earlier than 2008-04-24 | J | 16h | 16h |
| 76 | 1.4.11.5 | Energy Cell Charge Overlay | 3d? | 2008-04-29 A | 2008-05-01 A |  | 100% |  |  | start no earlier than 2008-04-29 | J | 24h | 24h |
| 77 | 1.5 | **Game Class** | 4d | 2008-02-13 A | 2008-02-18 A |  | 100% |  |  |  | Dustin | 64h | 64h |
| 78 | 1.5.1 | Basic Implementation | 2d | 2008-02-13 A | 2008-02-14 A |  | 100% |  |  |  | Dustin | 16h | 16h |
| 79 | 1.5.2 | Testing | 1d | 2008-02-15 A | 2008-02-15 A | 78 | 100% |  |  |  | Dustin | 8h | 8h |
| 80 | 1.5.3 | Integration | 1d | 2008-02-18 A | 2008-02-18 A | 79 | 100% |  |  |  | Dustin | 8h | 8h |

| ID | WBS | Task | Duration | Start | Finish | Predecessors | Complete | Remaining | Total slack | Constraint | Resources | Work | Actual work |
| --- | --- | --- | --- | --- | --- | --- | --- | --- | --- | --- | --- | --- | --- |
| 81 | 1.6 | **Camera** | 55d | 2008-02-22 A | 2008-04-26 |  | 87% | 7.33d | 27d |  |  | 184h | 168h |
| 82 | 1.6.1 | Research | 1d | 2008-02-22 A | 2008-02-22 A |  | 100% |  |  | start no earlier than 2008-02-22 | Andrew | 8h | 8h |
| 83 | 1.6.2 | **Basic Implementation** | 3d | 2008-02-25 A | 2008-02-27 A | 82 | 100% |  |  |  | Andrew | 40h | 40h |
| 84 | 1.6.2.1 | 3rd Person Following | 1d | 2008-02-25 A | 2008-02-25 A |  | 100% |  |  |  | Andrew | 8h | 8h |
| 85 | 1.6.2.2 | Camera Rotation and Manipulation | 1d | 2008-02-27 A | 2008-02-27 A |  | 100% |  |  | start no earlier than 2008-02-27 | Andrew | 8h | 8h |
| 86 | 1.6.3 | **Player State** | 1d | 2008-03-28 A | 2008-03-28 A |  | 100% |  |  |  |  | 8h | 8h |
| 87 | 1.6.3.1 | Velocity-Based following | 1d | 2008-03-28 A | 2008-03-28 A | 83 | 100% |  |  | start no earlier than 2008-03-28 | Andrew | 8h | 8h |
| 88 | 1.6.4 | **State Switching** | 5d | 2008-03-05 A | 2008-03-10 A |  | 100% |  |  |  | Andrew | 72h | 72h |
| 89 | 1.6.4.1 | Oribital | 1d | 2008-03-05 A | 2008-03-05 A |  | 100% |  |  | start no earlier than 2008-03-05 | Andrew | 8h | 8h |
| 90 | 1.6.4.2 | Player | 1d | 2008-03-06 A | 2008-03-06 A | 89 | 100% |  |  |  | Andrew | 8h | 8h |
| 91 | 1.6.4.3 | WorldView | 1d | 2008-03-10 A | 2008-03-10 A |  | 100% |  |  | start no earlier than 2008-03-10 | Andrew | 8h | 8h |
| 92 | 1.6.4.4 | Smooth Transitions | 1d | 2008-03-07 A | 2008-03-07 A |  | 100% |  |  | start no earlier than 2008-03-07 | Andrew | 8h | 8h |
| 93 | 1.6.5 | Fly-By System | 3d | 2008-04-01 A | 2008-04-26 |  | 33% | 2d | 27d | start no earlier than 2008-04-04 | Andrew | 24h | 8h |
| 94 | 1.6.6 | Testing | 2d | 2008-02-28 A | 2008-02-29 A | 85 | 100% |  |  | start no earlier than 2008-02-29 | Andrew | 16h | 16h |
| 95 | 1.6.7 | Integration | 2d | 2008-03-03 A | 2008-03-04 A | 94 | 100% |  |  | start no earlier than 2008-03-03 | Andrew | 16h | 16h |
| 96 | 1.7 | **Font Manager** | 37d | 2008-02-26 A | 2008-04-08 |  | 99% | 0d | 0d |  | J | 680h | 580.44h |
| 97 | 1.7.1 | Research | 1d | 2008-02-26 A | 2008-02-26 A |  | 100% |  |  | start no earlier than 2008-02-26 | J | 8h | 8h |
| 98 | 1.7.2 | Font Class | 1d | 2008-02-27 A | 2008-02-27 A | 97 | 100% |  |  | start no earlier than 2008-02-27 | J | 8h | 8h |
| 99 | 1.7.3 | Basic Implementation | 4d | 2008-02-29 A | 2008-03-04 A | 98 | 100% |  |  | start no earlier than 2008-02-29 | J | 32h | 32h |
| 100 | 1.7.4 | **Advanced Font Effects** | 24d | 2008-03-12 A | 2008-04-08 A |  | 100% |  |  |  | J | 280h | 280h |
| 101 | 1.7.4.1 | Timed | 1d | 2008-03-12 A | 2008-03-12 A |  | 100% |  |  | start no earlier than 2008-03-10 | J | 8h | 8h |
| 102 | 1.7.4.2 | Flashing | 1d | 2008-03-13 A | 2008-03-13 A |  | 100% |  |  | start no earlier than 2008-03-13 | J | 8h | 8h |
| 103 | 1.7.4.3 | Scaling | 2d | 2008-03-17 A | 2008-03-18 A |  | 100% |  |  | start no earlier than 2008-03-17 | J | 16h | 16h |
| 104 | 1.7.4.4 | Fading | 2d | 2008-03-19 A | 2008-03-20 A | 103 | 100% |  |  |  | J | 16h | 16h |
| 105 | 1.7.4.5 | Pop-Up | 2d | 2008-03-21 A | 2008-03-22 A | 104 | 100% |  |  |  | J | 16h | 16h |
| 106 | 1.7.4.6 | Scrolling Combat Text | 2d | 2008-04-03 A | 2008-04-04 A |  | 100% |  |  | start no earlier than 2008-04-03 | J | 16h | 16h |
| 107 | 1.7.4.7 | Automatic Kearning with Metrics | 2d | 2008-04-07 A | 2008-04-08 A |  | 100% |  |  | start no earlier than 2008-04-15 | J | 16h | 16h |
| 108 | 1.7.5 | Class Refactoring | 1d | 2008-03-14 A | 2008-03-14 A |  | 100% |  |  | start no earlier than 2008-03-14 | J | 8h | 8h |
| 109 | 1.7.6 | Testing | 2d | 2008-03-05 A | 2008-03-06 A |  | 100% |  |  | start no earlier than 2008-03-25 | J | 16h | 16h |
| 110 | 1.7.7 | Integration | 4d | 2008-03-07 A | 2008-03-11 A | 109 | 100% |  |  |  | J | 32h | 32h |

| ID | WBS | Task | Duration | Start | Finish | Predecessors | Complete | Constraint | Resources | Work | Actual work |
| --- | --- | --- | --- | --- | --- | --- | --- | --- | --- | --- | --- |
| 111 | 1.8 | **Menu System** | 41d | 2008-03-11 A | 2008-04-26 A |  | 100% |  |  | 184h | 184h |
| 112 | 1.8.1 | Basic Implementation | 1d | 2008-03-11 A | 2008-03-11 A |  | 100% | start no earlier than 2008-03-11 | Andrew | 8h | 8h |
| 113 | 1.8.2 | Menu Scripts | 2d | 2008-03-12 A | 2008-03-13 A | 112 | 100% | start no earlier than 2008-03-05 | Andrew | 16h | 16h |
| 114 | 1.8.3 | **System Logic** | 11d | 2008-03-14 A | 2008-03-26 A |  | 100% |  |  | 80h | 80h |
| 115 | 1.8.3.1 | Option Trees | 3d | 2008-03-14 A | 2008-03-17 A | 113 | 100% |  | Andrew | 24h | 24h |
| 116 | 1.8.3.2 | Option Selection and Representation | 2d | 2008-03-18 A | 2008-03-19 A | 115 | 100% |  | Andrew | 16h | 16h |
| 117 | 1.8.3.3 | Function Table | 2d | 2008-03-20 A | 2008-03-21 A | 116 | 100% | start no earlier than 2008-03-12 | Andrew | 16h | 16h |
| 118 | 1.8.3.4 | Game Objects as Menu Options | 3d | 2008-03-24 A | 2008-03-26 A | 117 | 100% | start no earlier than 2008-03-13 | Andrew | 24h | 24h |
| 119 | 1.8.4 | Advanced Visual Effects | 2d | 2008-04-25 A | 2008-04-26 A |  | 100% | start no earlier than 2008-04-25 | Andrew | 16h | 16h |
| 120 | 1.8.5 | Player Profiles | 3d | 2008-04-22 A | 2008-04-24 A |  | 100% | start no earlier than 2008-04-22 | Andrew | 24h | 24h |
| 121 | 1.8.6 | Testing | 2d | 2008-03-27 A | 2008-03-28 A | 118 | 100% |  | Andrew | 16h | 16h |
| 122 | 1.8.7 | Integration | 3d | 2008-03-29 A | 2008-04-01 A | 121 | 100% | start no earlier than 2008-03-17 | Andrew | 24h | 24h |
| 123 | 1.9 | **2D Menu System** | 12d? | 2008-04-28 A | 2008-05-10 A |  | 100% |  | Andrew | 192h | 192h |
| 124 | 1.9.1 | Basic Logic | 1d | 2008-04-28 A | 2008-04-28 A |  | 100% | start no earlier than 2008-04-28 | Andrew | 8h | 8h |
| 125 | 1.9.2 | XML Scripting | 3d | 2008-04-29 A | 2008-05-01 A | 124 | 100% | start no earlier than 2008-04-29 | Andrew | 24h | 24h |
| 126 | 1.9.3 | Auto Formatting | 2d | 2008-05-02 A | 2008-05-03 A | 125 | 100% | start no earlier than 2008-05-01 | Andrew | 16h | 16h |
| 127 | 1.9.4 | Profile Integration | 1d? | 2008-05-05 A | 2008-05-05 A | 126, 241 | 100% |  | Andrew | 8h | 8h |
| 128 | 1.9.5 | Achievements Integration | 1d? | 2008-05-06 A | 2008-05-06 A | 127, 245 | 100% |  | Andrew | 8h | 8h |
| 129 | 1.9.6 | Testing | 2d | 2008-05-07 A | 2008-05-08 A | 128 | 100% | start no earlier than 2008-05-01 | Andrew | 16h | 16h |
| 130 | 1.9.7 | Integration | 2d | 2008-05-09 A | 2008-05-10 A | 129 | 100% | start no earlier than 2008-05-01 | Andrew | 16h | 16h |
| 131 | 1.10 | **Object Manager** | 38d | 2008-02-19 A | 2008-04-03 A |  | 100% |  |  | 40h | 40h |
| 132 | 1.10.1 | Basic Implementation | 1d | 2008-02-19 A | 2008-02-19 A |  | 100% | start no earlier than 2008-02-19 | Dustin | 8h | 8h |
| 133 | 1.10.2 | Add Physics Engine | 1d | 2008-03-21 A | 2008-03-21 A | 132, 53 | 100% | start no earlier than 2008-03-21 | Dustin | 8h | 8h |
| 134 | 1.10.3 | Add Sound Engine | 2d | 2008-04-02 A | 2008-04-03 A | 132, 206 | 100% | start no earlier than 2008-03-31 | Dustin | 16h | 16h |
| 135 | 1.10.4 | Add Render Engine | 1d | 2008-02-25 A | 2008-02-25 A | 132, 7 | 100% | start no earlier than 2008-02-26 | Dustin | 8h | 8h |
| 136 | 1.10.5 | Testing | 1d | 2008-02-26 A | 2008-02-26 A | 135 | 100% |  |  |  |  |
| 137 | 1.10.6 | Integration | 1d | 2008-02-27 A | 2008-02-27 A | 136 | 100% |  |  |  |  |

| ID | WBS | Task | Duration | Start | Finish | Predecessors | Complete | Constraint | Resources | Work | Actual work |
| --- | --- | --- | --- | --- | --- | --- | --- | --- | --- | --- | --- |
| 138 | 1.11 | **Game State Machine** | 45d | 2008-02-20 A | 2008-04-12 A |  | 100% |  |  | 96h | 96h |
| 139 | 1.11.1 | Research | 1d | 2008-02-20 A | 2008-02-20 A |  | 100% | start no earlier than 2008-02-20 | Dustin | 8h | 8h |
| 140 | 1.11.2 | Menu State | 2d | 2008-02-21 A | 2008-04-04 A | 139 | 100% | start no earlier than 2008-02-19 | Dustin | 16h | 16h |
| 141 | 1.11.3 | Game State | 1d | 2008-02-22 A | 2008-02-22 A | 139 | 100% | start no earlier than 2008-02-22 | Dustin | 8h | 8h |
| 142 | 1.11.4 | Pause State | 1d | 2008-02-28 A | 2008-02-28 A | 139 | 100% | start no earlier than 2008-03-05 | Dustin | 8h | 8h |
| 143 | 1.11.5 | Credit State | 3d | 2008-02-29 A | 2008-04-01 A | 142 | 100% |  | Dustin | 24h | 24h |
| 144 | 1.11.6 | Win State | 2d | 2008-03-10 A | 2008-03-11 A |  | 100% |  | Dustin | 16h | 16h |
| 145 | 1.11.7 | Testing | 1d | 2008-04-11 A | 2008-04-11 A |  | 100% | start no earlier than 2008-04-11 | Dustin | 8h | 8h |
| 146 | 1.11.8 | Integration | 1d | 2008-04-12 A | 2008-04-12 A |  | 100% | start no earlier than 2008-04-12 | Dustin | 8h | 8h |
| 147 | 1.11.9 | Atom Movement | 4d | 2008-04-07 A | 2008-04-10 A |  | 100% | start no earlier than 2008-04-07 |  |  |  |
| 148 | 1.12 | **Player Class** | 1d | 2008-02-13 A | 2008-02-13 A |  | 100% |  | Jacob | 16h | 16h |
| 149 | 1.12.1 | Implementation | 1d | 2008-02-13 A | 2008-02-13 A |  | 100% |  | Jacob | 8h | 8h |
| 150 | 1.13 | **Player State Machine** | 25d | 2008-02-14 A | 2008-03-15 A |  | 100% |  | Jacob | 320h | 320h |
| 151 | 1.13.1 | Research | 2d | 2008-02-14 A | 2008-02-15 A | 149 | 100% |  | Jacob | 16h | 16h |
| 152 | 1.13.2 | Orbital State | 2d | 2008-02-18 A | 2008-02-19 A | 151 | 100% |  | Jacob | 16h | 16h |
| 153 | 1.13.3 | Slingshot Mode | 3d | 2008-03-13 A | 2008-03-15 A |  | 100% | start no earlier than 2008-03-13 | Jacob | 24h | 24h |
| 154 | 1.13.4 | Speed Boost | 2d | 2008-03-03 A | 2008-03-04 A |  | 100% | start no earlier than 2008-03-10 | Jacob | 16h | 16h |
| 155 | 1.13.5 | Navigation State | 2d | 2008-02-20 A | 2008-02-21 A |  | 100% | start no earlier than 2008-02-20 | Jacob | 16h | 16h |
| 156 | 1.13.6 | Collection State | 2d | 2008-02-22 A | 2008-02-25 A | 152 | 100% | start no earlier than 2008-02-22 | Jacob | 16h | 16h |
| 157 | 1.13.7 | Testing | 1d | 2008-02-26 A | 2008-02-26 A | 156 | 100% | start no earlier than 2008-02-19 | Jacob | 8h | 8h |
| 158 | 1.13.8 | Integration | 1d | 2008-02-27 A | 2008-02-27 A | 157 | 100% | start no earlier than 2008-02-21 | Jacob | 8h | 8h |
| 159 | 1.14 | Testing | 1d | 2008-02-28 A | 2008-02-28 A | 158 | 100% |  | Jacob | 8h | 8h |
| 160 | 1.15 | Integration | 1d | 2008-02-29 A | 2008-02-29 A | 159 | 100% |  | Jacob | 8h | 8h |
| 161 | 1.16 | Atom Movement | 4d | 2008-04-05 A | 2008-04-09 A |  | 100% | start no earlier than 2008-04-05 | Jacob | 32h | 32h |

| ID | WBS | Task | Duration | Start | Finish | Predecessors | Complete | Remaining | Total slack | Constraint | Resources | Work | Actual work |
| --- | --- | --- | --- | --- | --- | --- | --- | --- | --- | --- | --- | --- | --- |
| 162 | 1.17 | **Level Manager** | 58.5d? | 2008-02-13 A | 2008-04-23 |  | 99% | 0d? | 0d |  | Tom | 2056h | 1242.4h |
| 163 | 1.17.1 | Atom, Electron, and Bond Classes/Structures | 1d | 2008-02-13 A | 2008-02-13 A |  | 100% |  |  | start no earlier than 2008-02-13 | Tom | 8h | 8h |
| 164 | 1.17.2 | Object Relationships | 2d | 2008-02-14 A | 2008-02-15 A | 163 | 100% |  |  |  | Tom | 16h | 16h |
| 165 | 1.17.3 | Starting Level | 3d | 2008-02-20 A | 2008-02-22 A |  | 100% |  |  | start no earlier than 2008-02-19 | Tom | 24h | 24h |
| 166 | 1.17.4 | File I/O | 2d | 2008-03-06 A | 2008-03-07 A | 163 | 100% |  |  | start no earlier than 2008-03-06 | Tom | 16h | 16h |
| 167 | 1.17.5 | **Game Logic** | 55.5d | 2008-02-18 A | 2008-04-23 |  | 99% | 0d | 0d |  | Tom | 900h | 472h |
| 168 | 1.17.5.1 | Bond Creation | 2d | 2008-02-18 A | 2008-02-19 A |  | 100% |  |  | start no earlier than 2008-02-15 | Tom | 16h | 16h |
| 169 | 1.17.5.2 | Bond Destruction | 2d | 2008-02-25 A | 2008-02-26 A | 168, 164 | 100% |  |  | start no earlier than 2008-02-25 | Tom | 16h | 16h |
| 170 | 1.17.5.3 | **Goal Checking** | 48.5d | 2008-02-27 A | 2008-04-23 A |  | 100% |  |  |  | Tom | 424h | 424h |
| 171 | 1.17.5.3.1 | Builder Mode | 2d | 2008-02-27 A | 2008-02-28 A |  | 100% |  |  | start no earlier than 2008-02-27 | Tom | 16h | 16h |
| 172 | 1.17.5.3.2 | Time Attack | 2.5d | 2008-04-21 A | 2008-04-23 A |  | 100% |  |  | start no earlier than 2008-04-21 | Tom | 20h | 20h |
| 173 | 1.17.6 | **Power-Ups** | 25d? | 2008-03-17 A | 2008-04-14 |  | 99% | 0d? | 0d |  | Tom | 256h | 94.4h |
| 174 | 1.17.6.1 | Object Class Set-Up | 1d | 2008-03-17 A | 2008-03-17 A |  | 100% |  |  | start no earlier than 2008-03-17 | Tom | 8h | 8h |
| 175 | 1.17.6.2 | State Class Set-Up | 2d? | 2008-03-18 A | 2008-03-19 A | 174 | 100% |  |  | start no earlier than 2008-03-16 | Tom | 16h | 16h |
| 176 | 1.17.6.3 | Effect Application | 3d | 2008-03-31 A | 2008-04-02 A | 175 | 100% |  |  | start no earlier than 2008-03-31 | Tom | 24h | 24h |
| 177 | 1.17.6.4 | Integration | 1d | 2008-04-14 A | 2008-04-14 A |  | 100% |  |  | start no earlier than 2008-04-14 | Tom | 8h | 8h |
| 178 | 1.17.7 | **Atom Movement** | 6d? | 2008-04-07 A | 2008-04-12 |  | 99% | 0d? | 0d |  | Tom | 88h | 56h |
| 179 | 1.17.7.1 | Create Molecule Functionality | 2d? | 2008-04-07 A | 2008-04-08 A |  | 100% |  |  | start no earlier than 2008-04-07 | Tom | 16h | 16h |
| 180 | 1.17.7.2 | Integrate Molecules with Bonds | 2d? | 2008-04-09 A | 2008-04-10 A |  | 100% |  |  | start no earlier than 2008-04-09 | Tom | 16h | 16h |
| 181 | 1.17.7.3 | Integrate Atom/Bond Movement | 2d? | 2008-04-11 A | 2008-04-12 A |  | 100% |  |  | start no earlier than 2008-04-11 | Tom | 16h | 16h |
| 182 | 1.17.8 | **World Box** | 26d | 2008-02-29 A | 2008-03-29 |  | 99% | 0d | 0d |  | Tom | 240h | 48h |
| 183 | 1.17.8.1 | Testing | 2d | 2008-02-29 A | 2008-03-21 A |  | 100% |  |  | start no earlier than 2008-02-29 | Tom | 16h | 16h |
| 184 | 1.17.8.2 | Integration | 2d | 2008-03-03 A | 2008-03-29 A |  | 100% |  |  | start no earlier than 2008-03-03 | Tom | 16h | 16h |
| 185 | 1.17.9 | Dark Matter Hazards | 1d | 2008-04-16 A | 2008-04-16 A |  | 100% |  |  | start no earlier than 2008-04-16 | Tom | 8h | 8h |

| ID | WBS | Task | Duration | Start | Finish | Predecessors | Complete | Constraint | Resources | Work | Actual work |
| --- | --- | --- | --- | --- | --- | --- | --- | --- | --- | --- | --- |
| 186 | 1.17.10 | **Sphere Sky Box** | 2d | 2008-04-14 A | 2008-04-15 A |  | 100% |  | Dustin | 32h | 32h |
| 187 | 1.17.10.1 | Multi-Texture Effect | 1d | 2008-04-14 A | 2008-04-14 A |  | 100% | start no earlier than 2008-04-14 | Dustin | 8h | 8h |
| 188 | 1.17.10.2 | Integration | 1d | 2008-04-15 A | 2008-04-15 A | 187 | 100% | start no earlier than 2008-04-15 | Dustin | 8h | 8h |
| 189 | 1.18 | **Level Editor** | 36d? | 2008-03-10 A | 2008-04-19 A |  | 100% |  | Tom | 360h | 360h |
| 190 | 1.18.1 | Interface | 1d | 2008-03-10 A | 2008-03-10 A |  | 100% | start no earlier than 2008-03-10 | Tom | 8h | 8h |
| 191 | 1.18.2 | Atom Placement | 2d | 2008-03-11 A | 2008-03-12 A |  | 100% | start no earlier than 2008-03-11 | Tom | 16h | 16h |
| 192 | 1.18.3 | File I/O | 2d | 2008-03-13 A | 2008-03-14 A |  | 100% | start no earlier than 2008-03-13 | Tom | 16h | 16h |
| 193 | 1.18.4 | Re-do Atom/Quark Placement | 1d? | 2008-04-15 A | 2008-04-15 A |  | 100% | start no earlier than 2008-04-15 | Tom | 8h | 8h |
| 194 | 1.18.5 | World Box | 1d? | 2008-04-17 A | 2008-04-17 A |  | 100% | start no earlier than 2008-04-17 | Tom | 8h | 8h |
| 195 | 1.18.6 | Dark Matter | 1d? | 2008-04-18 A | 2008-04-18 A |  | 100% | start no earlier than 2008-04-18 | Tom | 8h | 8h |
| 196 | 1.18.7 | Power Ups | 1d? | 2008-04-19 A | 2008-04-19 A |  | 100% | start no earlier than 2008-04-19 | Tom | 8h | 8h |
| 197 | 1.19 | **Sound Engine** | 13d | 2008-03-25 A | 2008-04-08 A |  | 100% |  | Mike | 224h | 224h |
| 198 | 1.19.1 | Data Structures | 2d | 2008-03-25 A | 2008-03-26 A |  | 100% | start no earlier than 2008-03-25 | Mike | 16h | 16h |
| 199 | 1.19.2 | DirectSound Interface | 2d | 2008-03-27 A | 2008-03-28 A | 198 | 100% |  | Mike | 16h | 16h |
| 200 | 1.19.3 | **Wave Manager** | 4d | 2008-04-04 A | 2008-04-08 A |  | 100% |  | Mike | 64h | 64h |
| 201 | 1.19.3.1 | Basic Implementation | 1d | 2008-04-04 A | 2008-04-04 A | 199 | 100% | start no earlier than 2008-04-04 | Mike | 8h | 8h |
| 202 | 1.19.3.2 | File I/O | 1d | 2008-04-05 A | 2008-04-05 A | 201 | 100% |  | Mike | 8h | 8h |
| 203 | 1.19.3.3 | Testing | 1d | 2008-04-07 A | 2008-04-07 A | 202 | 100% |  | Mike | 8h | 8h |
| 204 | 1.19.3.4 | Intergration | 1d | 2008-04-08 A | 2008-04-08 A | 203 | 100% |  | Mike | 8h | 8h |
| 205 | 1.19.4 | Testing | 2d | 2008-03-29 A | 2008-03-31 A |  | 100% | start no earlier than 2008-03-29 | Mike | 16h | 16h |
| 206 | 1.19.5 | Integration | 1d | 2008-04-01 A | 2008-04-01 A | 205 | 100% |  | Mike | 8h | 8h |
| 207 | 1.20 | **Particle Manager** | 14d | 2008-03-03 A | 2008-03-18 A |  | 100% |  |  | 56h | 56h |
| 208 | 1.20.1 | Particle Class | 2d | 2008-03-04 A | 2008-03-05 A |  | 100% | start no earlier than 2008-03-04 | Dustin | 16h | 16h |
| 209 | 1.20.2 | Emitter Class | 2d | 2008-03-06 A | 2008-03-07 A |  | 100% | start no earlier than 2008-03-06 |  |  |  |
| 210 | 1.20.3 | Manager Class | 1d | 2008-03-03 A | 2008-03-03 A |  | 100% | start no earlier than 2008-03-07 |  |  |  |
| 211 | 1.20.4 | Testing | 3d | 2008-03-12 A | 2008-03-14 A | 209 | 100% | start no earlier than 2008-03-12 | Dustin | 24h | 24h |
| 212 | 1.20.5 | Integration | 2d | 2008-03-17 A | 2008-03-18 A | 211 | 100% | start no earlier than 2008-03-17 | Dustin | 16h | 16h |

| ID | WBS | Task | Duration | Start | Finish | Predecessors | Complete | Remaining | Total slack | Constraint | Resources | Work | Actual work |
| --- | --- | --- | --- | --- | --- | --- | --- | --- | --- | --- | --- | --- | --- |
| 213 | 1.21 | **Player Profile System** | 9d | 2008-04-16 A | 2008-04-25 A |  | 100% |  |  |  | Dustin | 144h | 144h |
| 214 | 1.21.1 | Class Set-Up | 1d | 2008-04-16 A | 2008-04-16 A |  | 100% |  |  | start no earlier than 2008-04-16 | Dustin | 8h | 8h |
| 215 | 1.21.2 | File I/O | 1d | 2008-04-17 A | 2008-04-17 A | 214 | 100% |  |  | start no earlier than 2008-03-13 | Dustin | 8h | 8h |
| 216 | 1.21.3 | Achievements | 4d | 2008-04-18 A | 2008-04-22 A | 215 | 100% |  |  | start no earlier than 2008-03-14 | Dustin | 32h | 32h |
| 217 | 1.21.4 | Testing | 1d | 2008-04-23 A | 2008-04-23 A | 216 | 100% |  |  | start no earlier than 2008-03-20 | Dustin | 8h | 8h |
| 218 | 1.21.5 | Integration | 2d | 2008-04-24 A | 2008-04-25 A | 217 | 100% |  |  | start no earlier than 2008-03-21 | Dustin | 16h | 16h |
| 219 | 1.22 | **Shader Creation** | 54d | 2008-02-15 A | 2008-04-19 |  | 94% | 3.38d | 33d |  | Andrew | 552h | 229.65h |
| 220 | 1.22.1 | Research | 4d | 2008-04-02 A | 2008-04-05 A |  | 100% |  |  | start no earlier than 2008-03-31 | Andrew | 24h | 24h |
| 221 | 1.22.2 | Glow Shader | 2d | 2008-04-10 A | 2008-04-11 |  | 50% | 1d | 40d | start no earlier than 2008-04-10 | Andrew | 16h | 8h |
| 222 | 1.22.3 | Motion Blur | 1d | 2008-02-15 A | 2008-02-15 A |  | 100% |  |  | start no earlier than 2008-04-18 | Andrew | 8h | 8h |
| 223 | 1.22.4 | Dynamic Lighting | 3d | 2008-04-07 A | 2008-04-09 A |  | 100% |  |  | start no earlier than 2008-04-08 | Andrew | 24h | 24h |
| 224 | 1.22.5 | Testing | 2d | 2008-04-14 A | 2008-04-15 A |  | 100% |  |  | start no earlier than 2008-04-15 | Andrew | 16h | 16h |
| 225 | 1.22.6 | Integration | 4d | 2008-04-16 A | 2008-04-19 A | 224 | 100% |  |  |  | Andrew | 32h | 32h |
| 226 | 1.23 | **Particle Editor** | 21d | 2008-03-05 A | 2008-03-28 A |  | 100% |  |  |  | Jacob | 352h | 352h |
| 227 | 1.23.1 | Basic Implementation | 1d | 2008-03-05 A | 2008-03-05 A |  | 100% |  |  | start no earlier than 2008-03-05 | Jacob | 8h | 8h |
| 228 | 1.23.2 | Interface | 2d | 2008-03-06 A | 2008-03-07 A | 227 | 100% |  |  | start no earlier than 2008-03-06 | Jacob | 16h | 16h |
| 229 | 1.23.3 | File I/O | 1d | 2008-03-10 A | 2008-03-10 A | 228 | 100% |  |  |  | Jacob | 8h | 8h |
| 230 | 1.23.4 | **Effect Creation** | 11d | 2008-03-12 A | 2008-03-24 A |  | 100% |  |  |  | Jacob | 120h | 120h |
| 231 | 1.23.4.1 | Bonding Effect | 1d | 2008-03-12 A | 2008-03-12 A |  | 100% |  |  |  | Jacob | 8h | 8h |
| 232 | 1.23.4.2 | Quark to Atom Collision Effect | 1d | 2008-03-20 A | 2008-03-20 A |  | 100% |  |  | start no earlier than 2008-03-20 | Jacob | 8h | 8h |
| 233 | 1.23.4.3 | Atom to Atom Collision Effect | 1d | 2008-03-21 A | 2008-03-21 A |  | 100% |  |  | start no earlier than 2008-03-21 | Jacob | 8h | 8h |
| 234 | 1.23.4.4 | Electron Absorbtion Effect | 1d | 2008-03-24 A | 2008-03-24 A |  | 100% |  |  | start no earlier than 2008-03-24 | Jacob | 8h | 8h |
| 235 | 1.23.5 | Testing | 2d | 2008-03-25 A | 2008-03-26 A |  | 100% |  |  | start no earlier than 2008-03-25 | Jacob | 16h | 16h |
| 236 | 1.23.6 | Integration | 2d | 2008-03-27 A | 2008-03-28 A | 235 | 100% |  |  | start no earlier than 2008-03-27 | Jacob | 16h | 16h |
| 237 | 1.24 | Play Testing | 5d | 2008-04-28 A | 2008-05-02 A |  | 100% |  |  | start no earlier than 2008-04-28 | Jacob | 40h | 40h |

| ID | WBS | Task | Duration | Start | Finish | Predecessors | Complete | Constraint | Resources | Work | Actual work |
| --- | --- | --- | --- | --- | --- | --- | --- | --- | --- | --- | --- |
| 238 | 1.25 | **Profile System** | 3d | 2008-04-28 A | 2008-04-30 A |  | 100% |  | Dustin | 48h | 48h |
| 239 | 1.25.1 | Data Structures and Design | 1d | 2008-04-28 A | 2008-04-28 A |  | 100% | start no earlier than 2008-04-16 | Dustin | 8h | 8h |
| 240 | 1.25.2 | Testing | 1d | 2008-04-29 A | 2008-04-29 A | 239 | 100% | start no earlier than 2008-04-16 | Dustin | 8h | 8h |
| 241 | 1.25.3 | Integration | 1d | 2008-04-30 A | 2008-04-30 A | 240 | 100% | start no earlier than 2008-04-16 | Dustin | 8h | 8h |
| 242 | 1.26 | **Achievement System** | 7d | 2008-05-01 A | 2008-05-08 A |  | 100% |  | Dustin | 112h | 112h |
| 243 | 1.26.1 | Achievement Manager | 1d | 2008-05-01 A | 2008-05-01 A |  | 100% | start no earlier than 2008-05-01 | Dustin | 8h | 8h |
| 244 | 1.26.2 | Achievement Displays | 2d | 2008-05-02 A | 2008-05-03 A | 243 | 100% | start no earlier than 2008-05-01 | Dustin | 16h | 16h |
| 245 | 1.26.3 | Profile System Integration | 1d | 2008-05-05 A | 2008-05-05 A | 244 | 100% | start no earlier than 2008-05-01 | Dustin | 8h | 8h |
| 246 | 1.26.4 | Testing | 1d | 2008-05-06 A | 2008-05-06 A | 245 | 100% | start no earlier than 2008-05-01 | Dustin | 8h | 8h |
| 247 | 1.26.5 | Integration | 2d | 2008-05-07 A | 2008-05-08 A | 246 | 100% | start no earlier than 2008-05-01 | Dustin | 16h | 16h |
| 248 | 1.27 | **Level Creation** | 27d | 2008-04-16 A | 2008-05-15 A |  | 100% |  | Tom | 624h | 624h |
| 249 | 1.27.1 | **Campaign Mode** | 20d | 2008-04-21 A | 2008-05-12 A |  | 100% |  | Tom | 320h | 320h |
| 250 | 1.27.1.1 | Tutorial: Level 1 | 1d | 2008-04-21 A | 2008-04-21 A |  | 100% | start no earlier than 2008-04-21 | Tom | 8h | 8h |
| 251 | 1.27.1.2 | Tutorial: Level 2 | 2d | 2008-04-22 A | 2008-04-23 A | 250 | 100% | start no earlier than 2008-04-22 | Tom | 16h | 16h |
| 252 | 1.27.1.3 | Tutorial: Level 3 | 2d | 2008-04-24 A | 2008-04-25 A | 251 | 100% | start no earlier than 2008-04-24 | Tom | 16h | 16h |
| 253 | 1.27.1.4 | Tutorial: Level 4 | 3d | 2008-04-26 A | 2008-04-28 A | 252 | 100% | start no earlier than 2008-04-26 | Tom | 24h | 24h |
| 254 | 1.27.1.5 | Level 5 | 2d | 2008-04-29 A | 2008-04-30 A | 253 | 100% | start no earlier than 2008-04-29 | Tom | 16h | 16h |
| 255 | 1.27.1.6 | Level 6 | 2d | 2008-05-01 A | 2008-05-02 A |  | 100% | start no earlier than 2008-05-01 | Tom | 16h | 16h |
| 256 | 1.27.1.7 | Level 7 | 2d | 2008-05-03 A | 2008-05-05 A |  | 100% | start no earlier than 2008-05-03 | Tom | 16h | 16h |
| 257 | 1.27.1.8 | Level 8 | 2d | 2008-05-06 A | 2008-05-07 A |  | 100% | start no earlier than 2008-05-06 | Tom | 16h | 16h |
| 258 | 1.27.1.9 | Level 9 | 2d | 2008-05-08 A | 2008-05-09 A |  | 100% | start no earlier than 2008-05-08 | Tom | 16h | 16h |
| 259 | 1.27.1.10 | Level 10 | 2d | 2008-05-10 A | 2008-05-12 A |  | 100% | start no earlier than 2008-05-10 | Tom | 16h | 16h |
| 260 | 1.27.2 | **Additional Quickplay Levels** | 27d | 2008-04-16 A | 2008-05-15 A |  | 100% |  |  | 88h | 88h |
| 261 | 1.27.2.1 | Play Testing | 5d | 2008-04-16 A | 2008-04-21 A |  | 100% | start no earlier than 2008-04-16 | Jacob | 40h | 40h |
| 262 | 1.27.2.2 | Level Balancing | 3d | 2008-05-13 A | 2008-05-15 A | 261 | 100% | start no earlier than 2008-05-01 | Tom | 24h | 24h |
| 263 | 1.27.2.3 | Integration | 3d | 2008-04-23 A | 2008-04-25 A |  | 100% | start no earlier than 2008-04-23 | Jacob | 24h | 24h |

| ID | WBS | Task | Type | Duration | Start | Finish | Complete | Remaining | Total slack | Constraint | Resources | Work | Actual work |
| --- | --- | --- | --- | --- | --- | --- | --- | --- | --- | --- | --- | --- | --- |
| 264 | 1.28 | **Bug Fixes** |  | 11d? | 2008-05-05 A | 2008-05-16 A | 100% |  |  |  |  | 144h | 144h |
| 265 | 1.28.1 | Camera/Input and Menu bugs |  | 4d | 2008-05-12 A | 2008-05-15 A | 100% |  |  | start no earlier than 2008-05-12 | Andrew | 32h | 32h |
| 266 | 1.28.2 | HUD/Font bugs |  | 4d | 2008-05-12 A | 2008-05-15 A | 100% |  |  | start no earlier than 2008-05-12 | J | 32h | 32h |
| 267 | 1.28.3 | Object and GameState Bugs |  | 4d | 2008-05-12 A | 2008-05-15 A | 100% |  |  | start no earlier than 2008-05-12 | Dustin | 32h | 32h |
| 268 | 1.28.4 | Player State bugs |  | 5d | 2008-05-05 A | 2008-05-09 A | 100% |  |  | start no earlier than 2008-05-05 | Jacob | 40h | 40h |
| 269 | 1.28.5 | Memory Leaks |  | 1d? | 2008-05-16 A | 2008-05-16 A | 100% |  |  | start no earlier than 2008-03-20 | Tom | 8h | 8h |
| 270 | 1.29 | **Fine Tuning** |  | 6d | 2008-05-12 A | 2008-05-17 A | 100% |  |  |  |  | 120h | 120h |
| 271 | 1.29.1 | Fine Tune Slingshot |  | 3d | 2008-05-12 A | 2008-05-14 A | 100% |  |  | start no earlier than 2008-05-12 | Jacob | 24h | 24h |
| 272 | 1.29.2 | Final Integration |  | 2d | 2008-05-16 A | 2008-05-17 A | 100% |  |  | start no earlier than 2008-05-22 | Andrew; Dustin; J; Jacob; Mike; Tom | 96h | 96h |
| 273 | 1.30 | **Milestones** |  | 81d | 2008-02-25 | 2008-05-28 |  |  | 0d |  |  |  |  |
| 274 | 1.30.1 | Proof of Concept | milestone | 0d | 2008-02-25 | 2008-02-25 |  |  | 81d | start no earlier than 2008-02-25 |  |  |  |
| 275 | 1.30.2 | Feature Fragment 1 | milestone | 0d | 2008-03-10 | 2008-03-10 |  |  | 69d | start no earlier than 2008-03-10 |  |  |  |
| 276 | 1.30.3 | Feature Fragment 2 | milestone | 0d | 2008-03-31 | 2008-03-31 |  |  | 51d | start no earlier than 2008-03-31 |  |  |  |
| 277 | 1.30.4 | Alpha | milestone | 0d | 2008-04-07 | 2008-04-07 |  |  | 45d | start no earlier than 2008-04-07 |  |  |  |
| 278 | 1.30.5 | Beta | milestone | 0d | 2008-04-28 | 2008-04-28 |  |  | 26d | start no earlier than 2008-04-28 |  |  |  |
| 279 | 1.30.6 | Final | milestone | 0d | 2008-05-19 | 2008-05-19 |  |  | 8d | start no earlier than 2008-05-19 |  |  |  |
| 280 | 1.30.7 | Archive | milestone | 0d | 2008-05-28 | 2008-05-28 |  |  | 0d | start no earlier than 2008-05-28 |  |  |  |
| 281 | 1.31 | **Assets** |  | 59d | 2008-02-25 A | 2008-05-02 | 99% | 0d | 22d |  |  | 88h | 88h |
| 282 | 1.31.1 | **3D Models** |  | 59d | 2008-02-25 | 2008-05-02 |  |  | 22d |  |  |  |  |
| 283 | 1.31.1.1 | Mesh_Electrons | milestone | 0d | 2008-02-28 | 2008-02-28 |  |  | 78d | start no earlier than 2008-02-28 |  |  |  |
| 284 | 1.31.1.2 | Mesh_Quark | milestone | 0d | 2008-02-25 | 2008-02-25 |  |  | 81d | start no earlier than 2008-02-25 |  |  |  |
| 285 | 1.31.1.3 | Mesh_Atoms | milestone | 0d | 2008-02-25 | 2008-02-25 |  |  | 81d | start no earlier than 2008-02-25 |  |  |  |
| 286 | 1.31.1.4 | Mesh_Dark_Matter | milestone | 0d | 2008-03-13 | 2008-03-13 |  |  | 66d | start no earlier than 2008-03-13 |  |  |  |
| 287 | 1.31.1.5 | Mesh_3D_Logo | milestone | 0d | 2008-05-02 | 2008-05-02 |  |  | 22d | start no earlier than 2008-05-02 |  |  |  |

| ID | WBS | Task | Type | Duration | Start | Finish | Complete | Remaining | Total slack | Constraint | Resources | Work | Actual work |
| --- | --- | --- | --- | --- | --- | --- | --- | --- | --- | --- | --- | --- | --- |
| 288 | 1.31.2 | **Music** |  | 0d | 2008-02-28 | 2008-02-28 |  |  | 78d |  |  |  |  |
| 289 | 1.31.2.1 | BGM_Menu | milestone | 0d | 2008-02-28 | 2008-02-28 |  |  | 78d | start no earlier than 2008-02-28 |  |  |  |
| 290 | 1.31.2.2 | BGM_Normal_Game | milestone | 0d | 2008-02-28 | 2008-02-28 |  |  | 78d | start no earlier than 2008-02-28 |  |  |  |
| 291 | 1.31.3 | **SFX** |  | 7d | 2008-03-28 A | 2008-04-04 | 99% | 0d | 46d |  |  | 24h | 24h |
| 292 | 1.31.3.1 | SFX_Menu_Confirmation | milestone | 0d | 2008-03-28 | 2008-03-28 |  |  | 53d | start no earlier than 2008-03-28 |  |  |  |
| 293 | 1.31.3.2 | SFX_Menu_Exit | milestone | 0d | 2008-03-28 | 2008-03-28 |  |  | 53d | start no earlier than 2008-03-28 |  |  |  |
| 294 | 1.31.3.3 | SFX_Quark_Collision_Atoms | milestone | 0d | 2008-03-28 | 2008-03-28 |  |  | 53d | start no earlier than 2008-03-28 |  |  |  |
| 295 | 1.31.3.4 | SFX_Quark_Collision_Electrons | milestone | 0d | 2008-03-28 | 2008-03-28 |  |  | 53d | start no earlier than 2008-03-28 |  |  |  |
| 296 | 1.31.3.5 | SFX_Bonds_Formed_Strong | milestone | 0d | 2008-03-28 | 2008-03-28 |  |  | 53d | start no earlier than 2008-03-28 |  |  |  |
| 297 | 1.31.3.6 | SFX_Bonds_Broken_Strong | milestone | 0d | 2008-03-28 | 2008-03-28 |  |  | 53d | start no earlier than 2008-03-28 |  |  |  |
| 298 | 1.31.3.7 | SFX_Energy_Alert | milestone | 0d | 2008-03-28 | 2008-03-28 |  |  | 53d | start no earlier than 2008-03-28 |  |  |  |
| 299 | 1.31.3.8 | Alpha SFX Implementation |  | 3d | 2008-04-02 A | 2008-04-04 A | 100% |  |  | start no earlier than 2008-04-02 | J | 24h | 24h |
| 300 | 1.31.4 | **2D Art** |  | 52d | 2008-03-03 A | 2008-04-30 | 99% | 0d | 23d |  |  | 64h | 64h |
| 301 | 1.31.4.1 | HUD_Polarity_Wheel_Unlit | milestone | 0d | 2008-03-31 | 2008-03-31 |  |  | 51d | start no earlier than 2008-03-31 |  |  |  |
| 302 | 1.31.4.2 | HUD_Polarity_Wheel_Unlit_Neutral | milestone | 0d | 2008-03-31 | 2008-03-31 |  |  | 51d | start no earlier than 2008-03-31 |  |  |  |
| 303 | 1.31.4.3 | HUD_Polarity_Wheel_Red | milestone | 0d | 2008-03-31 | 2008-03-31 |  |  | 51d | start no earlier than 2008-03-31 |  |  |  |
| 304 | 1.31.4.4 | HUD_Polarity_Wheel_Green | milestone | 0d | 2008-03-31 | 2008-03-31 |  |  | 51d | start no earlier than 2008-03-31 |  |  |  |
| 305 | 1.31.4.5 | HUD_Polarity_Wheel_Blue | milestone | 0d | 2008-03-31 | 2008-03-31 |  |  | 51d | start no earlier than 2008-03-31 |  |  |  |
| 306 | 1.31.4.6 | HUD_Polarity_Wheel_Neutral | milestone | 0d | 2008-03-31 | 2008-03-31 |  |  | 51d | start no earlier than 2008-03-31 |  |  |  |
| 307 | 1.31.4.7 | HUD_Energy_Bar | milestone | 0d | 2008-03-31 | 2008-03-31 |  |  | 51d | start no earlier than 2008-03-31 |  |  |  |
| 308 | 1.31.4.8 | HUD_Electron_Counters | milestone | 0d | 2008-03-31 | 2008-03-31 |  |  | 51d | start no earlier than 2008-03-31 |  |  |  |
| 309 | 1.31.4.9 | HUD_Atoms_Counters | milestone | 0d | 2008-03-31 | 2008-03-31 |  |  | 51d | start no earlier than 2008-03-31 |  |  |  |
| 310 | 1.31.4.10 | Implement A HUD Assets |  | 3d | 2008-03-31 A | 2008-04-02 A | 100% |  |  | start no earlier than 2008-03-31 | J | 24h | 24h |
| 311 | 1.31.4.11 | **Textures** |  | 20d | 2008-03-03 A | 2008-03-25 | 99% | 0d | 55d |  |  | 16h | 16h |
| 312 | 1.31.4.11.1 | Texture_Atom_Green | milestone | 0d | 2008-03-03 | 2008-03-03 |  |  | 75d | start no earlier than 2008-03-03 |  |  |  |
| 313 | 1.31.4.11.2 | Texture_Background | milestone | 0d | 2008-03-03 | 2008-03-03 |  |  | 75d | start no earlier than 2008-03-03 |  |  |  |
| 314 | 1.31.4.11.3 | Integrate FF2 Textures |  | 2d | 2008-03-24 A | 2008-03-25 A | 100% |  |  | start no earlier than 2008-03-24 | J | 16h | 16h |

| ID | WBS | Task | Duration | Start | Finish | Complete | Constraint | Resources | Work | Actual work |
| --- | --- | --- | --- | --- | --- | --- | --- | --- | --- | --- |
| 315 | 1.31.4.12 | **Particles** | 3d | 2008-04-28 A | 2008-04-30 A | 100% |  |  | 24h | 24h |
| 316 | 1.31.4.12.1 | Implement Animated Textures | 3d | 2008-04-28 A | 2008-04-30 A | 100% | start no earlier than 2008-04-28 | J | 24h | 24h |
